Schedule from GanttProject, 2017-05-22 to 2019-06-21.

## Calendars

- Project calendar: Mon-Fri working; Sat-Sun off.

## Schedule

| ID | WBS | Task | Type | Duration | Start | Finish | Predecessors | Constraint |
| --- | --- | --- | --- | --- | --- | --- | --- | --- |
| 1 | 1 | Preparation of production documentation |  | 30d | 2017-05-22 | 2017-06-30 |  |  |
| 2 | 2 | Preparation of assembly stations |  | 36d | 2017-06-01 | 2017-07-20 |  |  |
| 3 | 3 | Order materials - pipes, fittings |  | 19d | 2017-06-19 | 2017-07-13 |  |  |
| 4 | 4 | Order outer jacket |  | 5d | 2017-07-03 | 2017-07-07 | 1 |  |
| 5 | 5 | Order radiation screens |  | 5d | 2017-07-03 | 2017-07-07 | 1 |  |
| 6 | 6 | Order MLI |  | 15d | 2017-07-03 | 2017-07-21 | 1 |  |
| 7 | 7 | Order details |  | 15d | 2017-07-03 | 2017-07-21 | 1 |  |
| 8 | 8 | Order of compensators |  | 55d | 2017-07-03 | 2017-09-15 | 1 |  |
| 9 | 9 | Order flexible hoses |  | 40d | 2017-07-03 | 2017-08-25 | 1 |  |
| 10 | 10 | Delivery of materials for 5 Valve boxes and small ESS |  | 1d | 2017-07-14 | 2017-07-14 | 1, 3 |  |
| 11 | 11 | delivery of material for 5 boxes + CTL line |  | 1d | 2017-09-04 | 2017-09-04 |  | start no earlier than 2017-09-04 |
| 12 | 12 | delivery of material for 10 boxes |  | 1d | 2017-12-01 | 2017-12-01 |  | start no earlier than 2017-12-01 |
| 13 | 13 | delivery of material for 10 boxes and additional lines |  | 1d | 2018-04-02 | 2018-04-02 |  | start no earlier than 2018-04-02 |
| 14 | 14 | Delivery of 3 outer jacket + outer jacket for test stand |  | 10d | 2017-07-10 | 2017-07-21 | 4 |  |
| 15 | 15 | WUST Delivery of valves for 3 valve boxes and test stand | milestone | 0d | 2017-10-02 | 2017-10-02 |  | start no earlier than 2017-10-02 |
| 16 | 16 | WUST valves delivery for boxes 4, 5, 6, 7 | milestone | 0d | 2017-11-01 | 2017-11-01 |  | start no earlier than 2017-11-01 |
| 17 | 17 | WUST valves delivery for boxes 8, 9, 10, 11 | milestone | 0d | 2017-12-01 | 2017-12-01 |  |  |
| 18 | 18 | WUST valves delivery for boxes 12,13, 14, 15 | milestone | 0d | 2018-01-02 | 2018-01-02 |  |  |
| 19 | 19 | WUST valves delivery for boxes 16, 17, 18, 19 | milestone | 0d | 2018-02-01 | 2018-02-01 |  |  |
| 20 | 20 | WUST valves delivery for boxes 20, 21, 22, 23 | milestone | 0d | 2018-03-01 | 2018-03-01 |  |  |
| 21 | 21 | WUST valves delivery for boxes 24, 25, 26, 27 | milestone | 0d | 2018-04-02 | 2018-04-02 |  |  |
| 22 | 22 | WUST valves delivery for boxes 28, 29, 30 | milestone | 0d | 2018-05-01 | 2018-05-01 |  |  |
| 23 | 23 | WUST Delivery of temperature sensors for 1,2,3 VB+test | milestone | 0d | 2017-08-01 | 2017-08-01 |  | start no earlier than 2017-08-01 |
| 24 | 24 | WUST delivery of temperature sensors for 10 VB | milestone | 0d | 2017-09-04 | 2017-09-04 |  |  |
| 25 | 25 | WUST delivery of temperature sensors for 27 VB | milestone | 0d | 2017-09-25 | 2017-09-25 |  |  |
| 26 | 26 | WUST delivery of "warm" instrument. and valves for 3 VB+test | milestone | 0d | 2017-08-01 | 2017-08-01 |  |  |
| 27 | 27 | WUST delivery of "warm" instrument. and valves for 10 VB | milestone | 0d | 2017-09-04 | 2017-09-04 |  |  |
| 28 | 28 | WUST delivery of "warm" instrument. and valves for 27 VB | milestone | 0d | 2017-10-02 | 2017-10-02 |  |  |
| 29 | 29 | Delivery of the radiation screen for 3 valve box and test stand |  | 15d | 2017-07-10 | 2017-07-28 | 5 |  |
| 30 | 30 | 4 outer jacket delivery |  | 40d | 2017-07-10 | 2017-09-01 | 4 |  |
| 31 | 31 | 4 radiation screans delivery |  | 40d | 2017-07-10 | 2017-09-01 | 5 |  |
| 32 | 32 | 23 outer jacket delivery |  | 100d | 2017-07-10 | 2017-11-24 | 4 |  |
| 33 | 33 | 23 RS delivery |  | 100d | 2017-07-10 | 2017-11-24 | 5 |  |

| ID | WBS | Task | Duration | Start | Finish | Predecessors |
| --- | --- | --- | --- | --- | --- | --- |
| 34 | 34 | **Assembly box 1 and 2** | 86d | 2017-07-17 | 2017-11-13 |  |
| 35 | 34.1 | Welding preparation for 2 valve box | 3d | 2017-07-17 | 2017-07-19 | 10 |
| 36 | 34.2 | X-ray examination preparation | 1d | 2017-07-20 | 2017-07-20 | 35 |
| 37 | 34.3 | bending pipes for two valve box | 3d | 2017-07-17 | 2017-07-19 | 10 |
| 38 | 34.4 | Welding of two valve box process lines | 9d | 2017-10-02 | 2017-10-12 | 14, 15, 36 |
| 39 | 34.5 | Installation of temperature sensors for 2 valve box | 2d | 2017-10-13 | 2017-10-16 | 23, 38 |
| 40 | 34.6 | X-ray examination of 2 valve box | 2d | 2017-10-13 | 2017-10-16 | 38 |
| 41 | 34.7 | Helium leak testing process line | 2d | 2017-10-17 | 2017-10-18 | 40 |
| 42 | 34.8 | MLI wraping | 3d | 2017-10-19 | 2017-10-23 | 41 |
| 43 | 34.9 | Installation of radiation screens | 5d | 2017-10-24 | 2017-10-30 | 29, 42 |
| 44 | 34.10 | MLI wrapping on radiation screan | 2d | 2017-10-31 | 2017-11-01 | 43 |
| 45 | 34.11 | Assembly of outer jacket | 3d | 2017-10-31 | 2017-11-02 | 43 |
| 46 | 34.12 | Pressure and helium tests, valve seat tightness | 3d | 2017-11-03 | 2017-11-07 | 45 |
| 47 | 34.13 | Fiduciali measurement | 2d | 2017-11-08 | 2017-11-09 | 46 |
| 48 | 34.14 | Packing | 2d | 2017-11-10 | 2017-11-13 | 47 |
| 49 | 35 | **Assembly box 3 and TS** | 47d | 2017-10-17 | 2017-12-20 |  |
| 50 | 35.1 | Welding preparation for valve box no 3 and test stand | 2d | 2017-10-17 | 2017-10-18 | 39 |
| 51 | 35.2 | X-ray examination preparation box 3 & TS | 1d | 2017-10-19 | 2017-10-19 | 50 |
| 52 | 35.3 | Welding process pipes for box 3 & TS | 9d | 2017-11-03 | 2017-11-15 | 45 |
| 53 | 35.4 | Instalation of temp sensors for box 3 & TS | 2d | 2017-11-16 | 2017-11-17 | 52 |
| 54 | 35.5 | X-ray for box 3 & TS | 2d | 2017-11-20 | 2017-11-21 | 53 |
| 55 | 35.6 | helium leak test box 3 & TS | 2d | 2017-11-22 | 2017-11-23 | 54 |
| 56 | 35.7 | MLI wrapping | 2d | 2017-11-24 | 2017-11-27 | 55 |
| 57 | 35.8 | instalation of radiation screan | 5d | 2017-11-28 | 2017-12-04 | 56 |
| 58 | 35.9 | MLI on radiation screan | 2d | 2017-12-05 | 2017-12-06 | 57 |
| 59 | 35.10 | assemblly of outer jacket box 3 & TS | 3d | 2017-12-07 | 2017-12-11 | 58 |
| 60 | 35.11 | Pressure and helium test, valve sea tightness box 3 & TS | 3d | 2017-12-12 | 2017-12-14 | 59 |
| 61 | 35.12 | 3D measurments box 3 & TS | 2d | 2017-12-15 | 2017-12-18 | 60 |
| 62 | 35.13 | Packing box 3 & TS | 2d | 2017-12-19 | 2017-12-20 | 61 |

| ID | WBS | Task | Duration | Start | Finish | Predecessors |
| --- | --- | --- | --- | --- | --- | --- |
| 63 | 36 | **Assembly box 4, 5** | 51d | 2017-11-20 | 2018-01-29 |  |
| 64 | 36.1 | welding preparation for box 4 & 5 | 3d | 2017-11-20 | 2017-11-22 | 53 |
| 65 | 36.2 | x - ray for preparation 4, 5 | 1d | 2017-11-23 | 2017-11-23 | 64 |
| 66 | 36.3 | bending pipes for box 4, 5 | 3d | 2017-11-20 | 2017-11-22 | 53 |
| 67 | 36.4 | welding proces pips for box 4, 5 | 9d | 2017-12-12 | 2017-12-22 | 1, 16, 30, 59 |
| 68 | 36.5 | instalation of temp sensors box 4, 5 | 2d | 2017-12-25 | 2017-12-26 | 67 |
| 69 | 36.6 | x ray box 4, 5 | 2d | 2017-12-27 | 2017-12-28 | 68 |
| 70 | 36.7 | helium leak test box 4, 5 | 2d | 2017-12-29 | 2018-01-01 | 69 |
| 71 | 36.8 | MLI pp box 4, 5 | 3d | 2018-01-02 | 2018-01-04 | 70 |
| 72 | 36.9 | instalation of RS box 4, 5 | 5d | 2018-01-05 | 2018-01-11 | 31, 71 |
| 73 | 36.10 | MLI on RS box 4, 5 | 2d | 2018-01-12 | 2018-01-15 | 72 |
| 74 | 36.11 | assembly of OJ box 4, 5 | 3d | 2018-01-16 | 2018-01-18 | 73 |
| 75 | 36.12 | pressure and helium tests, valve seat tightnes box 4, 5 | 3d | 2018-01-19 | 2018-01-23 | 74 |
| 76 | 36.13 | fidutial measurment | 2d | 2018-01-24 | 2018-01-25 | 75 |
| 77 | 36.14 | packing box 4, 5 | 2d | 2018-01-26 | 2018-01-29 | 76 |
| 78 | 37 | **Assembly box 6, 7** | 52d | 2017-12-27 | 2018-03-08 |  |
| 79 | 37.1 | welding preparation for box 6, 7 | 2d | 2017-12-27 | 2017-12-28 | 68 |
| 80 | 37.2 | x ray examination for preparation box 6, 7 | 1d | 2017-12-29 | 2017-12-29 | 79 |
| 81 | 37.3 | bending pipes for box 6, 7 | 2d | 2017-12-27 | 2017-12-28 | 68 |
| 82 | 37.4 | PP welding box 6, 7 | 9d | 2018-01-19 | 2018-01-31 | 74 |
| 83 | 37.5 | temp sensors box 6, 7 | 2d | 2018-02-01 | 2018-02-02 | 82 |
| 84 | 37.6 | x ray PP box 6, 7 | 2d | 2018-02-05 | 2018-02-06 | 83 |
| 85 | 37.7 | helium leak test PP box 6, 7 | 2d | 2018-02-07 | 2018-02-08 | 84 |
| 86 | 37.8 | PP MLI wrapping box 6, 7 | 3d | 2018-02-09 | 2018-02-13 | 85 |
| 87 | 37.9 | RS assembly box 6, 7 | 5d | 2018-02-14 | 2018-02-20 | 86 |
| 88 | 37.10 | MLI wrapping on RS box 6, 7 | 2d | 2018-02-21 | 2018-02-22 | 87 |
| 89 | 37.11 | OJ assembly box 6, 7 | 3d | 2018-02-23 | 2018-02-27 | 88 |
| 90 | 37.12 | pressure and helium tests, valves seat test box 6, 7 | 3d | 2018-02-28 | 2018-03-02 | 89 |
| 91 | 37.13 | 3D measurment box 6, 7 | 2d | 2018-03-05 | 2018-03-06 | 90 |
| 92 | 37.14 | packing box 6, 7 | 2d | 2018-03-07 | 2018-03-08 | 91 |

| ID | WBS | Task | Duration | Start | Finish | Predecessors |
| --- | --- | --- | --- | --- | --- | --- |
| 93 | 38 | **Assembly box 8, 9** | 54d | 2018-02-05 | 2018-04-19 |  |
| 94 | 38.1 | welding preparation for box 8, 9 | 2d | 2018-02-05 | 2018-02-06 | 83 |
| 95 | 38.2 | x ray preparation box 8, 9 | 1d | 2018-02-07 | 2018-02-07 | 94 |
| 96 | 38.3 | bending pipes box 8, 9 | 2d | 2018-02-05 | 2018-02-06 | 83 |
| 97 | 38.4 | PP welding box 8, 9 | 9d | 2018-02-28 | 2018-03-12 | 17, 32, 89 |
| 98 | 38.5 | temp sensors box 8, 9 | 2d | 2018-03-13 | 2018-03-14 | 97 |
| 99 | 38.6 | x ray PP box 8, 9 | 2d | 2018-03-15 | 2018-03-16 | 98 |
| 100 | 38.7 | helium leak test PP box 8, 9 | 2d | 2018-03-19 | 2018-03-20 | 99 |
| 101 | 38.8 | PP MLI wrapping box 8, 9 | 5d | 2018-03-21 | 2018-03-27 | 100 |
| 102 | 38.9 | RS assembly box 8, 9 | 5d | 2018-03-28 | 2018-04-03 | 33, 101 |
| 103 | 38.10 | MLI wrapping on RS box 8, 9 | 2d | 2018-04-04 | 2018-04-05 | 102 |
| 104 | 38.11 | OJ assembly box 8, 9 | 3d | 2018-04-06 | 2018-04-10 | 103 |
| 105 | 38.12 | pressure and helium tests, valve seat test box 8, 9 | 3d | 2018-04-11 | 2018-04-13 | 104 |
| 106 | 38.13 | 3D measurment box 8, 9 | 2d | 2018-04-16 | 2018-04-17 | 105 |
| 107 | 38.14 | packing box 8, 9 | 2d | 2018-04-18 | 2018-04-19 | 106 |
| 108 | 39 | **Assembly box 10, 11** | 54d | 2018-03-15 | 2018-05-29 |  |
| 109 | 39.1 | welding preparation for box 10, 11 | 2d | 2018-03-15 | 2018-03-16 | 98 |
| 110 | 39.2 | x ray preparation box 10, 11 | 1d | 2018-03-19 | 2018-03-19 | 109 |
| 111 | 39.3 | bending pipes box 10, 11 | 2d | 2018-03-15 | 2018-03-16 | 98 |
| 112 | 39.4 | PP welding box 10, 11 | 9d | 2018-04-11 | 2018-04-23 | 104 |
| 113 | 39.5 | temp sensors box 10, 11 | 2d | 2018-04-24 | 2018-04-25 | 112 |
| 114 | 39.6 | x ray PP box 10, 11 | 2d | 2018-04-26 | 2018-04-27 | 113 |
| 115 | 39.7 | helium leak test PP box 10, 11 | 2d | 2018-04-30 | 2018-05-01 | 114 |
| 116 | 39.8 | PP MLI wrapping box 10, 11 | 3d | 2018-05-02 | 2018-05-04 | 115 |
| 117 | 39.9 | RS assembly box 10, 11 | 5d | 2018-05-07 | 2018-05-11 | 116 |
| 118 | 39.10 | MLI wrapping on RS box 10, 11 | 2d | 2018-05-14 | 2018-05-15 | 117 |
| 119 | 39.11 | OJ assembly box 10, 11 | 3d | 2018-05-16 | 2018-05-18 | 118 |
| 120 | 39.12 | pressure and helium test, valve seat test box 10, 11 | 3d | 2018-05-21 | 2018-05-23 | 119 |
| 121 | 39.13 | 3D measurment box 10, 11 | 2d | 2018-05-24 | 2018-05-25 | 120 |
| 122 | 39.14 | packing box 10, 11 | 2d | 2018-05-28 | 2018-05-29 | 121 |

| ID | WBS | Task | Duration | Start | Finish | Predecessors |
| --- | --- | --- | --- | --- | --- | --- |
| 123 | 40 | **Assembly box 12, 13** | 54d | 2018-04-24 | 2018-07-06 |  |
| 124 | 40.1 | welding preparation for box 12, 13 | 2d | 2018-04-24 | 2018-04-25 | 112 |
| 125 | 40.2 | x ray preparations for box 12 ,13 | 1d | 2018-04-26 | 2018-04-26 | 124 |
| 126 | 40.3 | bending pipes for box 12, 13 | 2d | 2018-04-24 | 2018-04-25 | 112 |
| 127 | 40.4 | PP welding box 12, 13 | 9d | 2018-05-21 | 2018-05-31 | 119 |
| 128 | 40.5 | temp sensors box 12, 13 | 2d | 2018-06-01 | 2018-06-04 | 127 |
| 129 | 40.6 | x ray PP box 12, 13 | 2d | 2018-06-05 | 2018-06-06 | 128 |
| 130 | 40.7 | helium leak test PP box 12, 13 | 2d | 2018-06-07 | 2018-06-08 | 129 |
| 131 | 40.8 | PP MLI wrapping box 12, 13 | 3d | 2018-06-11 | 2018-06-13 | 130 |
| 132 | 40.9 | RS assembly box 12, 13 | 5d | 2018-06-14 | 2018-06-20 | 131 |
| 133 | 40.10 | MLI wrapping on RS box 12, 13 | 2d | 2018-06-21 | 2018-06-22 | 132 |
| 134 | 40.11 | OJ assembly box 12, 13 | 3d | 2018-06-25 | 2018-06-27 | 133 |
| 135 | 40.12 | pressure and lea test, velve seat test box 12, 13 | 3d | 2018-06-28 | 2018-07-02 | 134 |
| 136 | 40.13 | 3D measurments box 12, 13 | 2d | 2018-07-03 | 2018-07-04 | 135 |
| 137 | 40.14 | packing box 12, 13 | 2d | 2018-07-05 | 2018-07-06 | 1, 136 |
| 138 | 41 | **Assembly box 14, 15** | 52d | 2018-06-05 | 2018-08-15 |  |
| 139 | 41.1 | welding preparations box 14, 15 | 2d | 2018-06-05 | 2018-06-06 | 128 |
| 140 | 41.2 | x ray preparations box 14, 15 | 1d | 2018-06-07 | 2018-06-07 | 139 |
| 141 | 41.3 | bending pipes for box 14, 15 | 2d | 2018-06-05 | 2018-06-06 | 128 |
| 142 | 41.4 | PP welding box 14, 15 | 9d | 2018-06-28 | 2018-07-10 | 134 |
| 143 | 41.5 | temp sensors box 14, 15 | 2d | 2018-07-11 | 2018-07-12 | 142 |
| 144 | 41.6 | x ray PP box 14, 15 | 2d | 2018-07-13 | 2018-07-16 | 143 |
| 145 | 41.7 | helium leak test PP box 14, 15 | 2d | 2018-07-17 | 2018-07-18 | 144 |
| 146 | 41.8 | PP MLI wrapping box 14, 15 | 3d | 2018-07-19 | 2018-07-23 | 145 |
| 147 | 41.9 | RS assembly box 14, 15 | 5d | 2018-07-24 | 2018-07-30 | 146 |
| 148 | 41.10 | MLI wrapping on RS box 14, 15 | 2d | 2018-07-31 | 2018-08-01 | 147 |
| 149 | 41.11 | OJ assembly box 14, 15 | 3d | 2018-08-02 | 2018-08-06 | 148 |
| 150 | 41.12 | pressure and leak test, valve seat test box 14, 15 | 3d | 2018-08-07 | 2018-08-09 | 149 |
| 151 | 41.13 | 3D measurments box 14, 15 | 2d | 2018-08-10 | 2018-08-13 | 150 |
| 152 | 41.14 | packing box 14, 15 | 2d | 2018-08-14 | 2018-08-15 | 151 |

| ID | WBS | Task | Duration | Start | Finish | Predecessors |
| --- | --- | --- | --- | --- | --- | --- |
| 153 | 42 | **Assembly box 16, 17** | 52d | 2018-07-13 | 2018-09-24 |  |
| 154 | 42.1 | welding preparations box 16, 17 | 2d | 2018-07-13 | 2018-07-16 | 143 |
| 155 | 42.2 | x ray preparations box 16, 17 | 1d | 2018-07-17 | 2018-07-17 | 154 |
| 156 | 42.3 | bending pipes for box 16, 17 | 2d | 2018-07-13 | 2018-07-16 | 143 |
| 157 | 42.4 | PP welding box 16, 17 | 9d | 2018-08-07 | 2018-08-17 | 149 |
| 158 | 42.5 | temp sensors box 16, 17 | 2d | 2018-08-20 | 2018-08-21 | 157 |
| 159 | 42.6 | x ray PP box 16, 17 | 2d | 2018-08-22 | 2018-08-23 | 158 |
| 160 | 42.7 | helium leak test PP box 16, 17 | 2d | 2018-08-24 | 2018-08-27 | 159 |
| 161 | 42.8 | PP MLI wrapping box 16, 17 | 3d | 2018-08-28 | 2018-08-30 | 160 |
| 162 | 42.9 | RS assembly box 16, 17 | 5d | 2018-08-31 | 2018-09-06 | 161 |
| 163 | 42.10 | MLI wrapping on RS box 16, 17 | 2d | 2018-09-07 | 2018-09-10 | 162 |
| 164 | 42.11 | OJ assembly box 16, 17 | 3d | 2018-09-11 | 2018-09-13 | 163 |
| 165 | 42.12 | pressure and leak test, valve seat test box 16, 17 | 3d | 2018-09-14 | 2018-09-18 | 164 |
| 166 | 42.13 | 3D measurments box 16, 17 | 2d | 2018-09-19 | 2018-09-20 | 165 |
| 167 | 42.14 | packing box 16, 17 | 2d | 2018-09-21 | 2018-09-24 | 166 |
| 168 | 43 | **Assembly box 18, 19** | 52d | 2018-08-22 | 2018-11-01 |  |
| 169 | 43.1 | welding preparations box 18, 19 | 2d | 2018-08-22 | 2018-08-23 | 158 |
| 170 | 43.2 | x ray preparations box 18, 19 | 1d | 2018-08-24 | 2018-08-24 | 169 |
| 171 | 43.3 | bending pipes for box 18, 19 | 2d | 2018-08-22 | 2018-08-23 | 158 |
| 172 | 43.4 | PP welding box 18, 19 | 9d | 2018-09-14 | 2018-09-26 | 164 |
| 173 | 43.5 | temp sensors box 18, 19 | 2d | 2018-09-27 | 2018-09-28 | 172 |
| 174 | 43.6 | x ray PP box 18, 19 | 2d | 2018-10-01 | 2018-10-02 | 173 |
| 175 | 43.7 | helium leak test PP box 18, 19 | 2d | 2018-10-03 | 2018-10-04 | 174 |
| 176 | 43.8 | PP MLI wrapping box 18, 19 | 3d | 2018-10-05 | 2018-10-09 | 175 |
| 177 | 43.9 | RS assembly box 18, 19 | 5d | 2018-10-10 | 2018-10-16 | 176 |
| 178 | 43.10 | MLI wrapping on RS box 18, 19 | 2d | 2018-10-17 | 2018-10-18 | 177 |
| 179 | 43.11 | OJ assembly box 18, 19 | 3d | 2018-10-19 | 2018-10-23 | 178 |
| 180 | 43.12 | pressure and leak test, valve seat test box 18, 19 | 3d | 2018-10-24 | 2018-10-26 | 179 |
| 181 | 43.13 | 3D measurments box 18, 19 | 2d | 2018-10-29 | 2018-10-30 | 180 |
| 182 | 43.14 | packing box 18, 19 | 2d | 2018-10-31 | 2018-11-01 | 181 |

| ID | WBS | Task | Duration | Start | Finish | Predecessors |
| --- | --- | --- | --- | --- | --- | --- |
| 183 | 44 | **Assembly box 20, 21** | 52d | 2018-10-01 | 2018-12-11 |  |
| 184 | 44.1 | welding preparations box 20, 21 | 2d | 2018-10-01 | 2018-10-02 | 173 |
| 185 | 44.2 | x ray preparations box 20, 21 | 1d | 2018-10-03 | 2018-10-03 | 184 |
| 186 | 44.3 | bending pipes for box 20, 21 | 2d | 2018-10-01 | 2018-10-02 | 173 |
| 187 | 44.4 | PP welding box 20, 21 | 9d | 2018-10-24 | 2018-11-05 | 179 |
| 188 | 44.5 | temp sensors box 20, 21 | 2d | 2018-11-06 | 2018-11-07 | 187 |
| 189 | 44.6 | x ray PP box 20, 21 | 2d | 2018-11-08 | 2018-11-09 | 188 |
| 190 | 44.7 | helium leak test PP box 20, 21 | 2d | 2018-11-12 | 2018-11-13 | 189 |
| 191 | 44.8 | PP MLI wrapping box 20, 21 | 3d | 2018-11-14 | 2018-11-16 | 190 |
| 192 | 44.9 | RS assembly box 20, 21 | 5d | 2018-11-19 | 2018-11-23 | 191 |
| 193 | 44.10 | MLI wrapping on RS box 20, 21 | 2d | 2018-11-26 | 2018-11-27 | 192 |
| 194 | 44.11 | OJ assembly box 20, 21 | 3d | 2018-11-28 | 2018-11-30 | 193 |
| 195 | 44.12 | pressure and leak test, valve seat test box 20, 21 | 3d | 2018-12-03 | 2018-12-05 | 194 |
| 196 | 44.13 | 3D measurments box 20, 21 | 2d | 2018-12-06 | 2018-12-07 | 195 |
| 197 | 44.14 | packing box 20, 21 | 2d | 2018-12-10 | 2018-12-11 | 196 |
| 198 | 45 | **Assembly box 22, 23** | 52d | 2018-11-08 | 2019-01-18 |  |
| 199 | 45.1 | welding preparations box 22, 23 | 2d | 2018-11-08 | 2018-11-09 | 188 |
| 200 | 45.2 | x ray preparations box 22, 23 | 1d | 2018-11-12 | 2018-11-12 | 199 |
| 201 | 45.3 | bending pipes for box 22, 23 | 2d | 2018-11-08 | 2018-11-09 | 188 |
| 202 | 45.4 | PP welding box 22, 23 | 9d | 2018-12-03 | 2018-12-13 | 194 |
| 203 | 45.5 | temp sensors box 22, 23 | 2d | 2018-12-14 | 2018-12-17 | 202 |
| 204 | 45.6 | x ray PP box 22, 23 | 2d | 2018-12-18 | 2018-12-19 | 203 |
| 205 | 45.7 | helium leak test PP box 22, 23 | 2d | 2018-12-20 | 2018-12-21 | 204 |
| 206 | 45.8 | PP MLI wrapping box 22, 23 | 3d | 2018-12-24 | 2018-12-26 | 205 |
| 207 | 45.9 | RS assembly box 22, 23 | 5d | 2018-12-27 | 2019-01-02 | 206 |
| 208 | 45.10 | MLI wrapping on RS box 22, 23 | 2d | 2019-01-03 | 2019-01-04 | 207 |
| 209 | 45.11 | OJ assembly box 22 ,23 | 3d | 2019-01-07 | 2019-01-09 | 208 |
| 210 | 45.12 | pressure and leak test, valve seat test box 22, 23 | 3d | 2019-01-10 | 2019-01-14 | 209 |
| 211 | 45.13 | 3D measurments box 22, 23 | 2d | 2019-01-15 | 2019-01-16 | 210 |
| 212 | 45.14 | packing box 22, 23 | 2d | 2019-01-17 | 2019-01-18 | 211 |

| ID | WBS | Task | Duration | Start | Finish | Predecessors |
| --- | --- | --- | --- | --- | --- | --- |
| 213 | 46 | **Assembly box 24, 25** | 52d | 2018-12-18 | 2019-02-27 |  |
| 214 | 46.1 | welding preparations box 24, 25 | 2d | 2018-12-18 | 2018-12-19 | 203 |
| 215 | 46.2 | x ray preparations box 24, 25 | 1d | 2018-12-20 | 2018-12-20 | 214 |
| 216 | 46.3 | bending pipes for box 24, 25 | 2d | 2018-12-18 | 2018-12-19 | 203 |
| 217 | 46.4 | PP welding box 24, 25 | 9d | 2019-01-10 | 2019-01-22 | 209 |
| 218 | 46.5 | temp sensors box 24, 25 | 2d | 2019-01-23 | 2019-01-24 | 217 |
| 219 | 46.6 | x ray PP box 24, 25 | 2d | 2019-01-25 | 2019-01-28 | 218 |
| 220 | 46.7 | helium leak test PP box 24, 25 | 2d | 2019-01-29 | 2019-01-30 | 219 |
| 221 | 46.8 | PP MLI wrapping box 24, 25 | 3d | 2019-01-31 | 2019-02-04 | 220 |
| 222 | 46.9 | RS assembly box 24, 25 | 5d | 2019-02-05 | 2019-02-11 | 221 |
| 223 | 46.10 | MLI wrapping on RS box 24, 25 | 2d | 2019-02-12 | 2019-02-13 | 222 |
| 224 | 46.11 | OJ assembly box 24, 25 | 3d | 2019-02-14 | 2019-02-18 | 223 |
| 225 | 46.12 | pressure and leak test, valve seat test box 24, 25 | 3d | 2019-02-19 | 2019-02-21 | 224 |
| 226 | 46.13 | 3D measurments box 24, 25 | 2d | 2019-02-22 | 2019-02-25 | 225 |
| 227 | 46.14 | packing box 24, 25 | 2d | 2019-02-26 | 2019-02-27 | 226 |
| 228 | 47 | **Assembly box 26, 27** | 52d | 2019-01-25 | 2019-04-08 |  |
| 229 | 47.1 | welding preparations box 26, 27 | 2d | 2019-01-25 | 2019-01-28 | 218 |
| 230 | 47.2 | x ray preparations box 26, 27 | 1d | 2019-01-29 | 2019-01-29 | 229 |
| 231 | 47.3 | bending pipes for box 26, 27 | 2d | 2019-01-25 | 2019-01-28 | 218 |
| 232 | 47.4 | PP welding box 26, 27 | 9d | 2019-02-19 | 2019-03-01 | 224 |
| 233 | 47.5 | temp sensors box 26, 27 | 2d | 2019-03-04 | 2019-03-05 | 232 |
| 234 | 47.6 | x ray PP box 26, 27 | 2d | 2019-03-06 | 2019-03-07 | 233 |
| 235 | 47.7 | helium leak test PP box 26, 27 | 2d | 2019-03-08 | 2019-03-11 | 234 |
| 236 | 47.8 | PP MLI wrapping box 26, 27 | 3d | 2019-03-12 | 2019-03-14 | 235 |
| 237 | 47.9 | RS assembly box 26, 27 | 5d | 2019-03-15 | 2019-03-21 | 236 |
| 238 | 47.10 | MLI wrapping on RS box 26, 27 | 2d | 2019-03-22 | 2019-03-25 | 237 |
| 239 | 47.11 | OJ assembly box 26, 27 | 3d | 2019-03-26 | 2019-03-28 | 238 |
| 240 | 47.12 | pressure and leak test, valve seat test box 26, 27 | 3d | 2019-03-29 | 2019-04-02 | 239 |
| 241 | 47.13 | 3D measurments box 26, 27 | 2d | 2019-04-03 | 2019-04-04 | 240 |
| 242 | 47.14 | packing box 26, 27 | 2d | 2019-04-05 | 2019-04-08 | 241 |

| ID | WBS | Task | Duration | Start | Finish | Predecessors | Constraint |
| --- | --- | --- | --- | --- | --- | --- | --- |
| 243 | 48 | **Assembly box 28, 29, 30** | 52d | 2019-03-06 | 2019-05-16 |  |  |
| 244 | 48.1 | welding preparations box 28, 29, 30 | 2d | 2019-03-06 | 2019-03-07 | 233 |  |
| 245 | 48.2 | x ray preparations box 28, 29, 30 | 1d | 2019-03-08 | 2019-03-08 | 244 |  |
| 246 | 48.3 | bending pipes for box 28, 29, 30 | 2d | 2019-03-06 | 2019-03-07 | 233 |  |
| 247 | 48.4 | PP welding box 28, 29, 30 | 9d | 2019-03-29 | 2019-04-10 | 239 |  |
| 248 | 48.5 | temp sensors box 28, 29, 30 | 2d | 2019-04-11 | 2019-04-12 | 247 |  |
| 249 | 48.6 | x ray PP box 28, 29, 30 | 2d | 2019-04-15 | 2019-04-16 | 248 |  |
| 250 | 48.7 | helium leak test PP box 28, 29, 30 | 2d | 2019-04-17 | 2019-04-18 | 249 |  |
| 251 | 48.8 | PP MLI wrapping box 28, 29, 30 | 3d | 2019-04-19 | 2019-04-23 | 250 |  |
| 252 | 48.9 | RS assembly box 28, 29, 30 | 5d | 2019-04-24 | 2019-04-30 | 251 |  |
| 253 | 48.10 | MLI wrapping on RS box 28, 29, 30 | 2d | 2019-05-01 | 2019-05-02 | 252 |  |
| 254 | 48.11 | OJ assembly box 28, 29, 30 | 3d | 2019-05-03 | 2019-05-07 | 253 |  |
| 255 | 48.12 | pressure and leak test, valve seat test box 28, 29, 30 | 3d | 2019-05-08 | 2019-05-10 | 254 |  |
| 256 | 48.13 | 3D measurments box 28, 29, 30 | 2d | 2019-05-13 | 2019-05-14 | 255 |  |
| 257 | 48.14 | packing box 28, 29, 30 | 2d | 2019-05-15 | 2019-05-16 | 256 |  |
| 258 | 49 | **TS Line assembly for Test Stand** | 106d | 2017-07-17 | 2017-12-11 |  |  |
| 259 | 49.1 | **CTL Modul M0.1** | 14d | 2017-07-17 | 2017-08-03 |  |  |
| 260 | 49.1.1 | Cuting and welding proces pipes | 1d | 2017-07-17 | 2017-07-17 | 10 | start no earlier than 2017-07-03 |
| 261 | 49.1.2 | assembly of sliding supports | 1d | 2017-07-18 | 2017-07-18 | 260 |  |
| 262 | 49.1.3 | RTG Test | 1d | 2017-07-19 | 2017-07-19 | 261 |  |
| 263 | 49.1.4 | Pressure test | 1d | 2017-07-20 | 2017-07-20 | 262 |  |
| 264 | 49.1.5 | helium leak test | 1d | 2017-07-21 | 2017-07-21 | 263 |  |
| 265 | 49.1.6 | MLI wrapping on proces pipes | 1d | 2017-07-24 | 2017-07-24 | 264 |  |
| 266 | 49.1.7 | TS Assembly | 3d | 2017-07-25 | 2017-07-27 | 265 |  |
| 267 | 49.1.8 | MLI wrapping on TS | 2d | 2017-07-28 | 2017-07-31 | 266 |  |
| 268 | 49.1.9 | VJ Assembly | 1d | 2017-08-01 | 2017-08-01 | 267 |  |
| 269 | 49.1.10 | LIN treatment, pressure test, helium leak test | 2d | 2017-08-02 | 2017-08-03 | 268 |  |

| ID | WBS | Task | Duration | Start | Finish | Predecessors | Constraint |
| --- | --- | --- | --- | --- | --- | --- | --- |
| 270 | 49.2 | **CTL Modul M2.1** | 14d | 2017-07-17 | 2017-08-03 |  |  |
| 271 | 49.2.1 | Cuting and welding proces pipes | 1d | 2017-07-17 | 2017-07-17 | 10 | start no earlier than 2017-07-03 |
| 272 | 49.2.2 | assembly of sliding supports | 1d | 2017-07-18 | 2017-07-18 | 271 |  |
| 273 | 49.2.3 | RTG Test | 1d | 2017-07-19 | 2017-07-19 | 272 |  |
| 274 | 49.2.4 | Pressure test | 1d | 2017-07-20 | 2017-07-20 | 273 |  |
| 275 | 49.2.5 | helium leak test | 1d | 2017-07-21 | 2017-07-21 | 274 |  |
| 276 | 49.2.6 | MLI wrapping on proces pipes | 1d | 2017-07-24 | 2017-07-24 | 275 |  |
| 277 | 49.2.7 | TS Assembly | 3d | 2017-07-25 | 2017-07-27 | 276 |  |
| 278 | 49.2.8 | MLI wrapping on TS | 2d | 2017-07-28 | 2017-07-31 | 277 |  |
| 279 | 49.2.9 | VJ Assembly | 1d | 2017-08-01 | 2017-08-01 | 278 |  |
| 280 | 49.2.10 | LIN treatment, pressure test, helium leak test | 2d | 2017-08-02 | 2017-08-03 | 279 |  |
| 281 | 49.3 | **CTL Modul M2.2** | 14d | 2017-08-02 | 2017-08-21 |  |  |
| 282 | 49.3.1 | Cuting and welding proces pipes | 1d | 2017-08-02 | 2017-08-02 | 10, 279 | start no earlier than 2017-07-03 |
| 283 | 49.3.2 | assembly of sliding supports | 1d | 2017-08-03 | 2017-08-03 | 282 |  |
| 284 | 49.3.3 | RTG Test | 1d | 2017-08-04 | 2017-08-04 | 283 |  |
| 285 | 49.3.4 | Pressure test | 1d | 2017-08-07 | 2017-08-07 | 284 |  |
| 286 | 49.3.5 | helium leak test | 1d | 2017-08-08 | 2017-08-08 | 285 |  |
| 287 | 49.3.6 | MLI wrapping on proces pipes | 1d | 2017-08-09 | 2017-08-09 | 286 |  |
| 288 | 49.3.7 | TS Assembly | 3d | 2017-08-10 | 2017-08-14 | 287 |  |
| 289 | 49.3.8 | MLI wrapping on TS | 2d | 2017-08-15 | 2017-08-16 | 288 |  |
| 290 | 49.3.9 | VJ Assembly | 1d | 2017-08-17 | 2017-08-17 | 289 |  |
| 291 | 49.3.10 | LIN treatment, pressure test, helium leak test | 2d | 2017-08-18 | 2017-08-21 | 290 |  |
| 292 | 49.4 | **CTL Modul M2.4** | 14d | 2017-08-02 | 2017-08-21 |  |  |
| 293 | 49.4.1 | Cuting and welding proces pipes | 1d | 2017-08-02 | 2017-08-02 | 10, 279 | start no earlier than 2017-07-03 |
| 294 | 49.4.2 | assembly of sliding supports | 1d | 2017-08-03 | 2017-08-03 | 293 |  |
| 295 | 49.4.3 | RTG Test | 1d | 2017-08-04 | 2017-08-04 | 294 |  |
| 296 | 49.4.4 | Pressure test | 1d | 2017-08-07 | 2017-08-07 | 295 |  |
| 297 | 49.4.5 | helium leak test | 1d | 2017-08-08 | 2017-08-08 | 296 |  |
| 298 | 49.4.6 | MLI wrapping on proces pipes | 1d | 2017-08-09 | 2017-08-09 | 297 |  |
| 299 | 49.4.7 | TS Assembly | 3d | 2017-08-10 | 2017-08-14 | 298 |  |
| 300 | 49.4.8 | MLI wrapping on TS | 2d | 2017-08-15 | 2017-08-16 | 299 |  |
| 301 | 49.4.9 | VJ Assembly | 1d | 2017-08-17 | 2017-08-17 | 300 |  |
| 302 | 49.4.10 | LIN treatment, pressure test, helium leak test | 2d | 2017-08-18 | 2017-08-21 | 301 |  |

| ID | WBS | Task | Duration | Start | Finish | Predecessors | Constraint |
| --- | --- | --- | --- | --- | --- | --- | --- |
| 303 | 49.5 | **CTL Modul M6.1** | 14d | 2017-08-18 | 2017-09-06 | 290, 301 |  |
| 304 | 49.5.1 | Cuting and welding proces pipes | 1d | 2017-08-18 | 2017-08-18 | 10 | start no earlier than 2017-07-31 |
| 305 | 49.5.2 | assembly of sliding supports | 1d | 2017-08-21 | 2017-08-21 | 304 |  |
| 306 | 49.5.3 | RTG Test | 1d | 2017-08-22 | 2017-08-22 | 305 |  |
| 307 | 49.5.4 | Pressure test | 1d | 2017-08-23 | 2017-08-23 | 306 |  |
| 308 | 49.5.5 | helium leak test | 1d | 2017-08-24 | 2017-08-24 | 307 |  |
| 309 | 49.5.6 | MLI wrapping on proces pipes | 1d | 2017-08-25 | 2017-08-25 | 308 |  |
| 310 | 49.5.7 | TS Assembly | 3d | 2017-08-28 | 2017-08-30 | 309 |  |
| 311 | 49.5.8 | MLI wrapping on TS | 2d | 2017-08-31 | 2017-09-01 | 310 |  |
| 312 | 49.5.9 | VJ Assembly | 1d | 2017-09-04 | 2017-09-04 | 311 |  |
| 313 | 49.5.10 | LIN treatment, pressure test, helium leak test | 2d | 2017-09-05 | 2017-09-06 | 312 |  |
| 314 | 49.6 | **CTL Modul M6.2** | 14d | 2017-08-18 | 2017-09-06 | 290, 301 |  |
| 315 | 49.6.1 | Cuting and welding proces pipes | 1d | 2017-08-18 | 2017-08-18 | 10 | start no earlier than 2017-07-31 |
| 316 | 49.6.2 | assembly of sliding supports | 1d | 2017-08-21 | 2017-08-21 | 315 |  |
| 317 | 49.6.3 | RTG Test | 1d | 2017-08-22 | 2017-08-22 | 316 |  |
| 318 | 49.6.4 | Pressure test | 1d | 2017-08-23 | 2017-08-23 | 317 |  |
| 319 | 49.6.5 | helium leak test | 1d | 2017-08-24 | 2017-08-24 | 318 |  |
| 320 | 49.6.6 | MLI wrapping on proces pipes | 1d | 2017-08-25 | 2017-08-25 | 319 |  |
| 321 | 49.6.7 | TS Assembly | 3d | 2017-08-28 | 2017-08-30 | 320 |  |
| 322 | 49.6.8 | MLI wrapping on TS | 2d | 2017-08-31 | 2017-09-01 | 321 |  |
| 323 | 49.6.9 | VJ Assembly | 1d | 2017-09-04 | 2017-09-04 | 322 |  |
| 324 | 49.6.10 | LIN treatment, pressure test, helium leak test | 2d | 2017-09-05 | 2017-09-06 | 323 |  |
| 325 | 49.7 | **CTL Modul M4.1** | 15d | 2017-09-05 | 2017-09-25 | 290, 301 |  |
| 326 | 49.7.1 | Cuting and welding proces pipes | 1d | 2017-09-05 | 2017-09-05 | 10, 323 | start no earlier than 2017-07-31 |
| 327 | 49.7.2 | assembly of sliding supports | 1d | 2017-09-06 | 2017-09-06 | 326 |  |
| 328 | 49.7.3 | RTG Test | 1d | 2017-09-07 | 2017-09-07 | 327 |  |
| 329 | 49.7.4 | Pressure test | 1d | 2017-09-08 | 2017-09-08 | 328 |  |
| 330 | 49.7.5 | helium leak test | 1d | 2017-09-11 | 2017-09-11 | 329 |  |
| 331 | 49.7.6 | MLI wrapping on proces pipes | 1d | 2017-09-12 | 2017-09-12 | 330 |  |
| 332 | 49.7.7 | TS Assembly | 3d | 2017-09-13 | 2017-09-15 | 331 |  |
| 333 | 49.7.8 | MLI wrapping on TS | 2d | 2017-09-18 | 2017-09-19 | 332 |  |
| 334 | 49.7.9 | VJ Assembly | 2d | 2017-09-20 | 2017-09-21 | 333 |  |
| 335 | 49.7.10 | LIN treatment, pressure test, helium leak test | 2d | 2017-09-22 | 2017-09-25 | 334 |  |

| ID | WBS | Task | Duration | Start | Finish | Predecessors | Constraint |
| --- | --- | --- | --- | --- | --- | --- | --- |
| 336 | 49.8 | **CTL Modul M8.1** | 15d | 2017-09-05 | 2017-09-25 | 290, 301 |  |
| 337 | 49.8.1 | Cuting and welding proces pipes | 1d | 2017-09-05 | 2017-09-05 | 10, 323 | start no earlier than 2017-07-31 |
| 338 | 49.8.2 | assembly of sliding supports | 1d | 2017-09-06 | 2017-09-06 | 337 |  |
| 339 | 49.8.3 | RTG Test | 1d | 2017-09-07 | 2017-09-07 | 338 |  |
| 340 | 49.8.4 | Pressure test | 1d | 2017-09-08 | 2017-09-08 | 339 |  |
| 341 | 49.8.5 | helium leak test | 1d | 2017-09-11 | 2017-09-11 | 340 |  |
| 342 | 49.8.6 | MLI wrapping on proces pipes | 1d | 2017-09-12 | 2017-09-12 | 341 |  |
| 343 | 49.8.7 | TS Assembly | 3d | 2017-09-13 | 2017-09-15 | 342 |  |
| 344 | 49.8.8 | MLI wrapping on TS | 2d | 2017-09-18 | 2017-09-19 | 343 |  |
| 345 | 49.8.9 | VJ Assembly | 2d | 2017-09-20 | 2017-09-21 | 344 |  |
| 346 | 49.8.10 | LIN treatment, pressure test, helium leak test | 2d | 2017-09-22 | 2017-09-25 | 345 |  |
| 347 | 49.9 | **CTL Modul M9.1** | 15d | 2017-09-22 | 2017-10-12 | 290, 301 |  |
| 348 | 49.9.1 | Cuting and welding proces pipes | 1d | 2017-09-22 | 2017-09-22 | 10, 334 | start no earlier than 2017-07-31 |
| 349 | 49.9.2 | assembly of sliding supports | 1d | 2017-09-25 | 2017-09-25 | 348 |  |
| 350 | 49.9.3 | RTG Test | 1d | 2017-09-26 | 2017-09-26 | 349 |  |
| 351 | 49.9.4 | Pressure test | 1d | 2017-09-27 | 2017-09-27 | 350 |  |
| 352 | 49.9.5 | helium leak test | 1d | 2017-09-28 | 2017-09-28 | 351 |  |
| 353 | 49.9.6 | MLI wrapping on proces pipes | 1d | 2017-09-29 | 2017-09-29 | 352 |  |
| 354 | 49.9.7 | TS Assembly | 3d | 2017-10-02 | 2017-10-04 | 353 |  |
| 355 | 49.9.8 | MLI wrapping on TS | 2d | 2017-10-05 | 2017-10-06 | 354 |  |
| 356 | 49.9.9 | VJ Assembly | 2d | 2017-10-09 | 2017-10-10 | 355 |  |
| 357 | 49.9.10 | LIN treatment, pressure test, helium leak test | 2d | 2017-10-11 | 2017-10-12 | 356 |  |
| 358 | 49.10 | **CTL Modul M10.1** | 15d | 2017-09-22 | 2017-10-12 | 290, 301 |  |
| 359 | 49.10.1 | Cuting and welding proces pipes | 1d | 2017-09-22 | 2017-09-22 | 10, 334 | start no earlier than 2017-07-31 |
| 360 | 49.10.2 | assembly of sliding supports | 1d | 2017-09-25 | 2017-09-25 | 359 |  |
| 361 | 49.10.3 | RTG Test | 1d | 2017-09-26 | 2017-09-26 | 360 |  |
| 362 | 49.10.4 | Pressure test | 1d | 2017-09-27 | 2017-09-27 | 361 |  |
| 363 | 49.10.5 | helium leak test | 1d | 2017-09-28 | 2017-09-28 | 362 |  |
| 364 | 49.10.6 | MLI wrapping on proces pipes | 1d | 2017-09-29 | 2017-09-29 | 363 |  |
| 365 | 49.10.7 | TS Assembly | 3d | 2017-10-02 | 2017-10-04 | 364 |  |
| 366 | 49.10.8 | MLI wrapping on TS | 2d | 2017-10-05 | 2017-10-06 | 365 |  |
| 367 | 49.10.9 | VJ Assembly | 2d | 2017-10-09 | 2017-10-10 | 366 |  |
| 368 | 49.10.10 | LIN treatment, pressure test, helium leak test | 2d | 2017-10-11 | 2017-10-12 | 367 |  |

| ID | WBS | Task | Duration | Start | Finish | Predecessors | Constraint |
| --- | --- | --- | --- | --- | --- | --- | --- |
| 369 | 49.11 | **CTL Modul M11.1** | 15d | 2017-10-11 | 2017-10-31 | 290, 301 |  |
| 370 | 49.11.1 | Cuting and welding proces pipes | 1d | 2017-10-11 | 2017-10-11 | 10, 356 | start no earlier than 2017-07-31 |
| 371 | 49.11.2 | assembly of sliding supports | 1d | 2017-10-12 | 2017-10-12 | 370 |  |
| 372 | 49.11.3 | RTG Test | 1d | 2017-10-13 | 2017-10-13 | 371 |  |
| 373 | 49.11.4 | Pressure test | 1d | 2017-10-16 | 2017-10-16 | 372 |  |
| 374 | 49.11.5 | helium leak test | 1d | 2017-10-17 | 2017-10-17 | 373 |  |
| 375 | 49.11.6 | MLI wrapping on proces pipes | 1d | 2017-10-18 | 2017-10-18 | 374 |  |
| 376 | 49.11.7 | TS Assembly | 3d | 2017-10-19 | 2017-10-23 | 375 |  |
| 377 | 49.11.8 | MLI wrapping on TS | 2d | 2017-10-24 | 2017-10-25 | 376 |  |
| 378 | 49.11.9 | VJ Assembly | 2d | 2017-10-26 | 2017-10-27 | 377 |  |
| 379 | 49.11.10 | LIN treatment, pressure test, helium leak test | 2d | 2017-10-30 | 2017-10-31 | 378 |  |
| 380 | 49.12 | **CTL Modul M1.1** | 23d | 2017-10-11 | 2017-11-10 | 290, 301 |  |
| 381 | 49.12.1 | Cuting and welding proces pipes - midle part | 1d | 2017-10-11 | 2017-10-11 | 10, 356 | start no earlier than 2017-07-31 |
| 382 | 49.12.2 | assembly of sliding supports | 1d | 2017-10-12 | 2017-10-12 | 381 |  |
| 383 | 49.12.3 | RTG Test | 1d | 2017-10-13 | 2017-10-13 | 382 |  |
| 384 | 49.12.4 | MLI wrapping on proces pipes - midle part | 1d | 2017-10-16 | 2017-10-16 | 383 |  |
| 385 | 49.12.5 | TS Assembly - midle part | 3d | 2017-10-17 | 2017-10-19 | 384 |  |
| 386 | 49.12.6 | MLI wrapping on TS - midle part | 2d | 2017-10-20 | 2017-10-23 | 385 |  |
| 387 | 49.12.7 | VJ Assembly - midle part | 2d | 2017-10-24 | 2017-10-25 | 386 |  |
| 388 | 49.12.8 | welding proces pipes | 2d | 2017-10-26 | 2017-10-27 | 387 |  |
| 389 | 49.12.9 | RTG test | 1d | 2017-10-30 | 2017-10-30 | 388 |  |
| 390 | 49.12.10 | MLI wrapping on proces pipes | 1d | 2017-10-31 | 2017-10-31 | 389 |  |
| 391 | 49.12.11 | TS assembly | 2d | 2017-11-01 | 2017-11-02 | 390 |  |
| 392 | 49.12.12 | MLI wrapping on TS | 2d | 2017-11-03 | 2017-11-06 | 391 |  |
| 393 | 49.12.13 | VJ Assembly | 2d | 2017-11-07 | 2017-11-08 | 392 |  |
| 394 | 49.12.14 | LIN treatment, pressure test, helium leak test | 2d | 2017-11-09 | 2017-11-10 | 393 |  |

| ID | WBS | Task | Duration | Start | Finish | Predecessors | Constraint |
| --- | --- | --- | --- | --- | --- | --- | --- |
| 395 | 49.13 | **CTL Modul M5.1** | 23d | 2017-11-09 | 2017-12-11 | 290, 301 |  |
| 396 | 49.13.1 | Cuting and welding proces pipes - midle part | 1d | 2017-11-09 | 2017-11-09 | 10, 393 | start no earlier than 2017-07-31 |
| 397 | 49.13.2 | assembly of sliding supports | 1d | 2017-11-10 | 2017-11-10 | 396 |  |
| 398 | 49.13.3 | RTG Test | 1d | 2017-11-13 | 2017-11-13 | 397 |  |
| 399 | 49.13.4 | MLI wrapping on proces pipes - midle part | 1d | 2017-11-14 | 2017-11-14 | 398 |  |
| 400 | 49.13.5 | TS Assembly - midle part | 3d | 2017-11-15 | 2017-11-17 | 399 |  |
| 401 | 49.13.6 | MLI wrapping on TS - midle part | 2d | 2017-11-20 | 2017-11-21 | 400 |  |
| 402 | 49.13.7 | VJ Assembly - midle part | 2d | 2017-11-22 | 2017-11-23 | 401 |  |
| 403 | 49.13.8 | welding proces pipes | 2d | 2017-11-24 | 2017-11-27 | 402 |  |
| 404 | 49.13.9 | RTG test | 1d | 2017-11-28 | 2017-11-28 | 403 |  |
| 405 | 49.13.10 | MLI wrapping on proces pipes | 1d | 2017-11-29 | 2017-11-29 | 404 |  |
| 406 | 49.13.11 | TS assembly | 2d | 2017-11-30 | 2017-12-01 | 405 |  |
| 407 | 49.13.12 | MLI wrapping on TS | 2d | 2017-12-04 | 2017-12-05 | 406 |  |
| 408 | 49.13.13 | VJ Assembly | 2d | 2017-12-06 | 2017-12-07 | 407 |  |
| 409 | 49.13.14 | LIN treatment, pressure test, helium leak test | 2d | 2017-12-08 | 2017-12-11 | 408 |  |
| 410 | 50 | **CTL Line assembly for BIG ESS** | 84d | 2017-11-13 | 2018-03-08 |  |  |
| 411 | 50.1 | **CTL Modul 4** | 32d | 2017-11-13 | 2017-12-26 |  |  |
| 412 | 50.1.1 | Cuting and welding proces pipes | 1d | 2017-12-08 | 2017-12-08 | 408 | start no earlier than 2017-07-03 |
| 413 | 50.1.2 | assembly of sliding supports | 1d | 2017-12-11 | 2017-12-11 | 412 |  |
| 414 | 50.1.3 | RTG Test | 1d | 2017-12-12 | 2017-12-12 | 413 |  |
| 415 | 50.1.4 | Pressure test | 1d | 2017-12-13 | 2017-12-13 | 414 |  |
| 416 | 50.1.5 | helium leak test | 1d | 2017-12-14 | 2017-12-14 | 415 |  |
| 417 | 50.1.6 | MLI wrapping on proces pipes | 1d | 2017-12-15 | 2017-12-15 | 416 |  |
| 418 | 50.1.7 | TS Assembly | 3d | 2017-12-18 | 2017-12-20 | 417 |  |
| 419 | 50.1.8 | MLI wrapping on TS | 2d | 2017-12-21 | 2017-12-22 | 418 |  |
| 420 | 50.1.9 | VJ Assembly | 2d | 2017-12-25 | 2017-12-26 | 419 |  |
| 421 | 50.1.10 | LIN treatment, pressure test, helium leak test | 2d | 2017-11-13 | 2017-11-14 |  |  |

| ID | WBS | Task | Duration | Start | Finish | Predecessors | Constraint |
| --- | --- | --- | --- | --- | --- | --- | --- |
| 422 | 50.2 | **CTL Modul 6.1** | 14d | 2017-12-08 | 2017-12-27 |  |  |
| 423 | 50.2.1 | Cuting and welding proces pipes | 1d | 2017-12-08 | 2017-12-08 | 408 | start no earlier than 2017-07-03 |
| 424 | 50.2.2 | assembly of sliding supports | 1d | 2017-12-11 | 2017-12-11 | 423 |  |
| 425 | 50.2.3 | RTG Test | 1d | 2017-12-12 | 2017-12-12 | 424 |  |
| 426 | 50.2.4 | Pressure test | 1d | 2017-12-13 | 2017-12-13 | 425 |  |
| 427 | 50.2.5 | helium leak test | 1d | 2017-12-14 | 2017-12-14 | 426 |  |
| 428 | 50.2.6 | MLI wrapping on proces pipes | 1d | 2017-12-15 | 2017-12-15 | 427 |  |
| 429 | 50.2.7 | TS Assembly | 3d | 2017-12-18 | 2017-12-20 | 428 |  |
| 430 | 50.2.8 | MLI wrapping on TS | 2d | 2017-12-21 | 2017-12-22 | 429 |  |
| 431 | 50.2.9 | VJ Assembly | 1d | 2017-12-25 | 2017-12-25 | 430 |  |
| 432 | 50.2.10 | LIN treatment, pressure test, helium leak test | 2d | 2017-12-26 | 2017-12-27 | 431 |  |
| 433 | 50.3 | **CTL Modul 6.2** | 14d | 2017-12-26 | 2018-01-12 |  |  |
| 434 | 50.3.1 | Cuting and welding proces pipes | 1d | 2017-12-26 | 2017-12-26 | 10, 431 | start no earlier than 2017-07-03 |
| 435 | 50.3.2 | assembly of sliding supports | 1d | 2017-12-27 | 2017-12-27 | 434 |  |
| 436 | 50.3.3 | RTG Test | 1d | 2017-12-28 | 2017-12-28 | 435 |  |
| 437 | 50.3.4 | Pressure test | 1d | 2017-12-29 | 2017-12-29 | 436 |  |
| 438 | 50.3.5 | helium leak test | 1d | 2018-01-01 | 2018-01-01 | 437 |  |
| 439 | 50.3.6 | MLI wrapping on proces pipes | 1d | 2018-01-02 | 2018-01-02 | 438 |  |
| 440 | 50.3.7 | TS Assembly | 3d | 2018-01-03 | 2018-01-05 | 439 |  |
| 441 | 50.3.8 | MLI wrapping on TS | 2d | 2018-01-08 | 2018-01-09 | 440 |  |
| 442 | 50.3.9 | VJ Assembly | 1d | 2018-01-10 | 2018-01-10 | 441 |  |
| 443 | 50.3.10 | LIN treatment, pressure test, helium leak test | 2d | 2018-01-11 | 2018-01-12 | 442 |  |
| 444 | 50.4 | **CTL Modul 6.3** | 14d | 2017-12-26 | 2018-01-12 |  |  |
| 445 | 50.4.1 | Cuting and welding proces pipes | 1d | 2017-12-26 | 2017-12-26 | 10, 431 | start no earlier than 2017-07-03 |
| 446 | 50.4.2 | assembly of sliding supports | 1d | 2017-12-27 | 2017-12-27 | 445 |  |
| 447 | 50.4.3 | RTG Test | 1d | 2017-12-28 | 2017-12-28 | 446 |  |
| 448 | 50.4.4 | Pressure test | 1d | 2017-12-29 | 2017-12-29 | 447 |  |
| 449 | 50.4.5 | helium leak test | 1d | 2018-01-01 | 2018-01-01 | 448 |  |
| 450 | 50.4.6 | MLI wrapping on proces pipes | 1d | 2018-01-02 | 2018-01-02 | 449 |  |
| 451 | 50.4.7 | TS Assembly | 3d | 2018-01-03 | 2018-01-05 | 450 |  |
| 452 | 50.4.8 | MLI wrapping on TS | 2d | 2018-01-08 | 2018-01-09 | 451 |  |
| 453 | 50.4.9 | VJ Assembly | 1d | 2018-01-10 | 2018-01-10 | 452 |  |
| 454 | 50.4.10 | LIN treatment, pressure test, helium leak test | 2d | 2018-01-11 | 2018-01-12 | 453 |  |

| ID | WBS | Task | Duration | Start | Finish | Predecessors | Constraint |
| --- | --- | --- | --- | --- | --- | --- | --- |
| 455 | 50.5 | **CTL Modul 9** | 14d | 2018-01-11 | 2018-01-30 | 442, 453 |  |
| 456 | 50.5.1 | Cuting and welding proces pipes | 1d | 2018-01-11 | 2018-01-11 | 10 | start no earlier than 2017-07-31 |
| 457 | 50.5.2 | assembly of sliding supports | 1d | 2018-01-12 | 2018-01-12 | 456 |  |
| 458 | 50.5.3 | RTG Test | 1d | 2018-01-15 | 2018-01-15 | 457 |  |
| 459 | 50.5.4 | Pressure test | 1d | 2018-01-16 | 2018-01-16 | 458 |  |
| 460 | 50.5.5 | helium leak test | 1d | 2018-01-17 | 2018-01-17 | 459 |  |
| 461 | 50.5.6 | MLI wrapping on proces pipes | 1d | 2018-01-18 | 2018-01-18 | 460 |  |
| 462 | 50.5.7 | TS Assembly | 3d | 2018-01-19 | 2018-01-23 | 461 |  |
| 463 | 50.5.8 | MLI wrapping on TS | 2d | 2018-01-24 | 2018-01-25 | 462 |  |
| 464 | 50.5.9 | VJ Assembly | 1d | 2018-01-26 | 2018-01-26 | 463 |  |
| 465 | 50.5.10 | LIN treatment, pressure test, helium leak test | 2d | 2018-01-29 | 2018-01-30 | 464 |  |
| 466 | 50.6 | **CTL Modul 1** | 15d | 2018-01-11 | 2018-01-31 | 442, 453 |  |
| 467 | 50.6.1 | Cuting and welding proces pipes | 1d | 2018-01-11 | 2018-01-11 | 10 | start no earlier than 2017-07-31 |
| 468 | 50.6.2 | assembly of sliding supports | 1d | 2018-01-12 | 2018-01-12 | 467 |  |
| 469 | 50.6.3 | RTG Test | 1d | 2018-01-15 | 2018-01-15 | 468 |  |
| 470 | 50.6.4 | Pressure test | 1d | 2018-01-16 | 2018-01-16 | 469 |  |
| 471 | 50.6.5 | helium leak test | 1d | 2018-01-17 | 2018-01-17 | 470 |  |
| 472 | 50.6.6 | MLI wrapping on proces pipes | 1d | 2018-01-18 | 2018-01-18 | 471 |  |
| 473 | 50.6.7 | TS Assembly | 3d | 2018-01-19 | 2018-01-23 | 472 |  |
| 474 | 50.6.8 | MLI wrapping on TS | 2d | 2018-01-24 | 2018-01-25 | 473 |  |
| 475 | 50.6.9 | VJ Assembly | 2d | 2018-01-26 | 2018-01-29 | 474 |  |
| 476 | 50.6.10 | LIN treatment, pressure test, helium leak test | 2d | 2018-01-30 | 2018-01-31 | 475 |  |
| 477 | 50.7 | **CTL Modul 5** | 15d | 2018-01-11 | 2018-01-31 | 442, 453 |  |
| 478 | 50.7.1 | Cuting and welding proces pipes | 1d | 2018-01-11 | 2018-01-11 | 10 | start no earlier than 2017-07-31 |
| 479 | 50.7.2 | assembly of sliding supports | 1d | 2018-01-12 | 2018-01-12 | 478 |  |
| 480 | 50.7.3 | RTG Test | 1d | 2018-01-15 | 2018-01-15 | 479 |  |
| 481 | 50.7.4 | Pressure test | 1d | 2018-01-16 | 2018-01-16 | 480 |  |
| 482 | 50.7.5 | helium leak test | 1d | 2018-01-17 | 2018-01-17 | 481 |  |
| 483 | 50.7.6 | MLI wrapping on proces pipes | 1d | 2018-01-18 | 2018-01-18 | 482 |  |
| 484 | 50.7.7 | TS Assembly | 3d | 2018-01-19 | 2018-01-23 | 483 |  |
| 485 | 50.7.8 | MLI wrapping on TS | 2d | 2018-01-24 | 2018-01-25 | 484 |  |
| 486 | 50.7.9 | VJ Assembly | 2d | 2018-01-26 | 2018-01-29 | 485 |  |
| 487 | 50.7.10 | LIN treatment, pressure test, helium leak test | 2d | 2018-01-30 | 2018-01-31 | 486 |  |

| ID | WBS | Task | Duration | Start | Finish | Predecessors | Constraint |
| --- | --- | --- | --- | --- | --- | --- | --- |
| 488 | 50.8 | **CTL Modul 7** | 15d | 2018-01-30 | 2018-02-19 | 442, 453 |  |
| 489 | 50.8.1 | Cuting and welding proces pipes | 1d | 2018-01-30 | 2018-01-30 | 10, 475 | start no earlier than 2017-07-31 |
| 490 | 50.8.2 | assembly of sliding supports | 1d | 2018-01-31 | 2018-01-31 | 489 |  |
| 491 | 50.8.3 | RTG Test | 1d | 2018-02-01 | 2018-02-01 | 490 |  |
| 492 | 50.8.4 | Pressure test | 1d | 2018-02-02 | 2018-02-02 | 491 |  |
| 493 | 50.8.5 | helium leak test | 1d | 2018-02-05 | 2018-02-05 | 492 |  |
| 494 | 50.8.6 | MLI wrapping on proces pipes | 1d | 2018-02-06 | 2018-02-06 | 493 |  |
| 495 | 50.8.7 | TS Assembly | 3d | 2018-02-07 | 2018-02-09 | 494 |  |
| 496 | 50.8.8 | MLI wrapping on TS | 2d | 2018-02-12 | 2018-02-13 | 495 |  |
| 497 | 50.8.9 | VJ Assembly | 2d | 2018-02-14 | 2018-02-15 | 496 |  |
| 498 | 50.8.10 | LIN treatment, pressure test, helium leak test | 2d | 2018-02-16 | 2018-02-19 | 497 |  |
| 499 | 50.9 | **CTL Modul 8** | 15d | 2018-01-30 | 2018-02-19 | 442, 453 |  |
| 500 | 50.9.1 | Cuting and welding proces pipes | 1d | 2018-01-30 | 2018-01-30 | 10, 475 | start no earlier than 2017-07-31 |
| 501 | 50.9.2 | assembly of sliding supports | 1d | 2018-01-31 | 2018-01-31 | 500 |  |
| 502 | 50.9.3 | RTG Test | 1d | 2018-02-01 | 2018-02-01 | 501 |  |
| 503 | 50.9.4 | Pressure test | 1d | 2018-02-02 | 2018-02-02 | 502 |  |
| 504 | 50.9.5 | helium leak test | 1d | 2018-02-05 | 2018-02-05 | 503 |  |
| 505 | 50.9.6 | MLI wrapping on proces pipes | 1d | 2018-02-06 | 2018-02-06 | 504 |  |
| 506 | 50.9.7 | TS Assembly | 3d | 2018-02-07 | 2018-02-09 | 505 |  |
| 507 | 50.9.8 | MLI wrapping on TS | 2d | 2018-02-12 | 2018-02-13 | 506 |  |
| 508 | 50.9.9 | VJ Assembly | 2d | 2018-02-14 | 2018-02-15 | 507 |  |
| 509 | 50.9.10 | LIN treatment, pressure test, helium leak test | 2d | 2018-02-16 | 2018-02-19 | 508 |  |
| 510 | 50.10 | **CTL Modul 10** | 15d | 2018-02-16 | 2018-03-08 | 442, 453 |  |
| 511 | 50.10.1 | Cuting and welding proces pipes | 1d | 2018-02-16 | 2018-02-16 | 10, 497 | start no earlier than 2017-07-31 |
| 512 | 50.10.2 | assembly of sliding supports | 1d | 2018-02-19 | 2018-02-19 | 511 |  |
| 513 | 50.10.3 | RTG Test | 1d | 2018-02-20 | 2018-02-20 | 512 |  |
| 514 | 50.10.4 | Pressure test | 1d | 2018-02-21 | 2018-02-21 | 513 |  |
| 515 | 50.10.5 | helium leak test | 1d | 2018-02-22 | 2018-02-22 | 514 |  |
| 516 | 50.10.6 | MLI wrapping on proces pipes | 1d | 2018-02-23 | 2018-02-23 | 515 |  |
| 517 | 50.10.7 | TS Assembly | 3d | 2018-02-26 | 2018-02-28 | 516 |  |
| 518 | 50.10.8 | MLI wrapping on TS | 2d | 2018-03-01 | 2018-03-02 | 517 |  |
| 519 | 50.10.9 | VJ Assembly | 2d | 2018-03-05 | 2018-03-06 | 518 |  |
| 520 | 50.10.10 | LIN treatment, pressure test, helium leak test | 2d | 2018-03-07 | 2018-03-08 | 519 |  |

| ID | WBS | Task | Duration | Start | Finish | Predecessors | Constraint |
| --- | --- | --- | --- | --- | --- | --- | --- |
| 521 | 50.11 | **CTL Modul 11** | 30d | 2018-01-11 | 2018-02-21 | 442, 453 |  |
| 522 | 50.11.1 | Cuting and welding proces pipes - midle part | 1d | 2018-02-16 | 2018-02-16 | 10, 497 | start no earlier than 2017-07-31 |
| 523 | 50.11.2 | assembly of sliding supports | 1d | 2018-02-19 | 2018-02-19 | 522 |  |
| 524 | 50.11.3 | RTG Test | 1d | 2018-02-20 | 2018-02-20 | 523 |  |
| 525 | 50.11.4 | TS Assembly - midle part | 1d | 2018-01-11 | 2018-01-11 |  |  |
| 526 | 50.11.5 | MLI wrapping on proces pipes - midle part | 1d | 2018-02-21 | 2018-02-21 | 524 |  |
| 527 | 50.11.6 | MLI wrapping on TS - midle part | 2d | 2018-01-12 | 2018-01-15 | 525 |  |
| 528 | 50.11.7 | VJ Assembly - midle part | 2d | 2018-01-16 | 2018-01-17 | 527 |  |
| 529 | 50.11.8 | welding proces pipes | 2d | 2018-01-18 | 2018-01-19 | 528 |  |
| 530 | 50.11.9 | RTG test | 1d | 2018-01-22 | 2018-01-22 | 529 |  |
| 531 | 50.11.10 | MLI wrapping on proces pipes | 1d | 2018-01-23 | 2018-01-23 | 530 |  |
| 532 | 50.11.11 | TS assembly | 2d | 2018-01-24 | 2018-01-25 | 531 |  |
| 533 | 50.11.12 | MLI wrapping on TS | 2d | 2018-01-26 | 2018-01-29 | 532 |  |
| 534 | 50.11.13 | VJ Assembly | 2d | 2018-01-30 | 2018-01-31 | 533 |  |
| 535 | 50.11.14 | LIN treatment, pressure test, helium leak test | 2d | 2018-02-01 | 2018-02-02 | 534 |  |
| 536 | 50.12 | **CTL Modul 3** | 23d | 2018-02-01 | 2018-03-05 | 442, 453 |  |
| 537 | 50.12.1 | Cuting and welding proces pipes - midle part | 1d | 2018-02-01 | 2018-02-01 | 10, 534 | start no earlier than 2017-07-31 |
| 538 | 50.12.2 | assembly of sliding supports | 1d | 2018-02-02 | 2018-02-02 | 537 |  |
| 539 | 50.12.3 | RTG Test | 1d | 2018-02-05 | 2018-02-05 | 538 |  |
| 540 | 50.12.4 | MLI wrapping on proces pipes - midle part | 1d | 2018-02-06 | 2018-02-06 | 539 |  |
| 541 | 50.12.5 | TS Assembly - midle part | 3d | 2018-02-07 | 2018-02-09 | 540 |  |
| 542 | 50.12.6 | MLI wrapping on TS - midle part | 2d | 2018-02-12 | 2018-02-13 | 541 |  |
| 543 | 50.12.7 | VJ Assembly - midle part | 2d | 2018-02-14 | 2018-02-15 | 542 |  |
| 544 | 50.12.8 | welding proces pipes | 2d | 2018-02-16 | 2018-02-19 | 543 |  |
| 545 | 50.12.9 | RTG test | 1d | 2018-02-20 | 2018-02-20 | 544 |  |
| 546 | 50.12.10 | MLI wrapping on proces pipes | 1d | 2018-02-21 | 2018-02-21 | 545 |  |
| 547 | 50.12.11 | TS assembly | 2d | 2018-02-22 | 2018-02-23 | 546 |  |
| 548 | 50.12.12 | MLI wrapping on TS | 2d | 2018-02-26 | 2018-02-27 | 547 |  |
| 549 | 50.12.13 | VJ Assembly | 2d | 2018-02-28 | 2018-03-01 | 548 |  |
| 550 | 50.12.14 | LIN treatment, pressure test, helium leak test | 2d | 2018-03-02 | 2018-03-05 | 549 |  |

| ID | WBS | Task | Duration | Start | Finish | Predecessors | Constraint |
| --- | --- | --- | --- | --- | --- | --- | --- |
| 551 | 51 | **TS AUX Lines** | 27d | 2017-09-04 | 2017-10-10 |  |  |
| 552 | 51.1 | Cutting and welding proces pipes | 10d | 2017-09-04 | 2017-09-15 |  |  |
| 553 | 51.2 | X ray test | 2d | 2017-09-18 | 2017-09-19 | 552 |  |
| 554 | 51.3 | MLI wrapping | 3d | 2017-09-20 | 2017-09-22 | 553 |  |
| 555 | 51.4 | OJ Assembly | 6d | 2017-09-25 | 2017-10-02 | 554 |  |
| 556 | 51.5 | helium leak test | 3d | 2017-10-03 | 2017-10-05 | 555 |  |
| 557 | 51.6 | Pressure test | 3d | 2017-10-06 | 2017-10-10 | 556 |  |
| 558 | 52 | **CTL AUX Lines** | 38d | 2017-10-16 | 2017-12-06 |  |  |
| 559 | 52.1 | Cutting and welding proces pipes | 15d | 2017-10-16 | 2017-11-03 |  |  |
| 560 | 52.2 | X ray test | 2d | 2017-11-06 | 2017-11-07 | 559 |  |
| 561 | 52.3 | MLI wrapping | 5d | 2017-11-08 | 2017-11-14 | 560 |  |
| 562 | 52.4 | OJ Assembly | 10d | 2017-11-15 | 2017-11-28 | 561 |  |
| 563 | 52.5 | helium leak test | 3d | 2017-11-29 | 2017-12-01 | 562 |  |
| 564 | 52.6 | Pressure test | 3d | 2017-12-04 | 2017-12-06 | 563 |  |
| 565 | 53 | ESS installation VB | 120d | 2019-01-07 | 2019-06-21 | 197 | start no earlier than 2019-01-07 |
| 566 | 54 | ESS installation CTL gallery | 120d | 2019-01-07 | 2019-06-21 | 197 | start no earlier than 2019-01-07 |
| 567 | 55 | ESS installation Test Stand | 120d | 2018-01-08 | 2018-06-22 | 62, 409, 557 | start no earlier than 2018-01-08 |
